# My New Workspace

Schedule from MS Project, 2007-09-01 to 2007-11-12, costs in $.
Refurbish New Offices
Our Global Company

## Calendars

- Standard: Mon-Fri 08:00-12:00, 13:00-17:00; Sat-Sun off.

## Resources

| Resource | Group | Rate |
| --- | --- | --- |
| Laborer | External | 50 |
| Technician | Internal | 100 |
| Painter 1 | External | 65 |
| Painter 2 | External | 65 |

## Schedule

| ID | WBS | Task | Type | Duration | Start | Finish | Predecessors | Baseline start | Baseline finish | Baseline duration | Total slack | Free slack | Constraint | Deadline | Resources | Work | Cost | Baseline cost |
| --- | --- | --- | --- | --- | --- | --- | --- | --- | --- | --- | --- | --- | --- | --- | --- | --- | --- | --- |
| 1 | 1 | Project Start | milestone | 0d | 2007-09-01 08:00 | 2007-09-01 08:00 |  | 2007-09-01 08:00 | 2007-09-01 08:00 | 0d | 16.5d | 0d |  |  |  |  |  |  |
| 2 | 2 | **Staff Meeting** |  | 25.12d | 2007-10-08 08:00 | 2007-11-12 09:00 |  | 2007-10-08 08:00 | 2007-11-12 09:00 | 25.12d | 0d |  |  |  |  |  |  |  |
| 3 | 2.1 | Staff Meeting 1 |  | 1h | 2007-10-08 08:00 | 2007-10-08 09:00 |  | 2007-10-08 08:00 | 2007-10-08 09:00 | 1h | 25d |  | start no earlier than 2007-10-08 08:00 |  |  |  |  |  |
| 4 | 2.2 | Staff Meeting 2 |  | 1h | 2007-10-15 08:00 | 2007-10-15 09:00 |  | 2007-10-15 08:00 | 2007-10-15 09:00 | 1h | 20d |  | start no earlier than 2007-10-15 08:00 |  |  |  |  |  |
| 5 | 2.3 | Staff Meeting 3 |  | 1h | 2007-10-22 08:00 | 2007-10-22 09:00 |  | 2007-10-22 08:00 | 2007-10-22 09:00 | 1h | 15d |  | start no earlier than 2007-10-22 08:00 |  |  |  |  |  |
| 6 | 2.4 | Staff Meeting 4 |  | 1h | 2007-10-29 08:00 | 2007-10-29 09:00 |  | 2007-10-29 08:00 | 2007-10-29 09:00 | 1h | 10d |  | start no earlier than 2007-10-29 08:00 |  |  |  |  |  |
| 7 | 2.5 | Staff Meeting 5 |  | 1h | 2007-11-05 08:00 | 2007-11-05 09:00 |  | 2007-11-05 08:00 | 2007-11-05 09:00 | 1h | 5d |  | start no earlier than 2007-11-05 08:00 |  |  |  |  |  |
| 8 | 2.6 | Staff Meeting 6 |  | 1h | 2007-11-12 08:00 | 2007-11-12 09:00 |  | 2007-11-12 08:00 | 2007-11-12 09:00 | 1h | 0d |  | start no earlier than 2007-11-12 08:00 |  |  |  |  |  |
| 9 | 3 | **Paint the Walls** |  | 1d | 2007-09-03 08:00 | 2007-09-03 17:00 | 1 | 2007-09-03 08:00 | 2007-09-03 17:00 | 1d | 16.5d |  |  |  | Painter 1; Painter 2 | 32h | 2,080 | 2,080 |
| 10 | 3.1 | Paint the East Walls |  | 1d | 2007-09-03 08:00 | 2007-09-03 17:00 |  | 2007-09-03 08:00 | 2007-09-03 17:00 | 1d | 16.5d | 0d |  |  | Painter 1 | 8h | 520 | 520 |
| 11 | 3.2 | Paint the West Walls |  | 1d | 2007-09-03 08:00 | 2007-09-03 17:00 | 10SS | 2007-09-03 08:00 | 2007-09-03 17:00 | 1d | 16.5d | 0.5d |  |  | Painter 2 | 8h | 520 | 520 |
| 12 | 4 | Install Partitions |  | 1d | 2007-09-04 13:00 | 2007-09-05 17:00 | 11 | 2007-09-04 13:00 | 2007-09-05 17:00 | 1d | 16d | 0d |  |  | Laborer | 8h | 400 | 400 |
| 13 | 5 | Install Network Cables |  | 5.5d | 2007-09-04 13:00 | 2007-09-13 17:00 | 12SS | 2007-09-04 13:00 | 2007-09-13 17:00 | 5.5d | 16d | 0.5d |  |  | Technician; Laborer | 48h | 3,600 | 3,600 |
| 14 | 6 | Lay Carpet |  | 2d | 2007-09-14 13:00 | 2007-09-19 17:00 | 13 | 2007-09-14 13:00 | 2007-09-19 17:00 | 2d | 16d | 0.5d |  |  | Laborer | 16h | 800 | 800 |
| 15 | 7 | **Prepare Offices** |  | 8.5d | 2007-09-20 13:00 | 2007-10-02 17:00 |  | 2007-09-20 13:00 | 2007-10-02 17:00 | 8.5d | 16d |  |  |  |  | 40h | 2,400 | 2,400 |
| 16 | 7.1 | Assemble Furniture |  | 2d | 2007-09-20 13:00 | 2007-09-25 17:00 | 14 | 2007-09-20 13:00 | 2007-09-25 17:00 | 2d | 16d | 0d |  |  | Laborer | 16h | 800 | 800 |
| 17 | 7.2 | Hook up Computers |  | 1d | 2007-09-26 08:00 | 2007-09-26 17:00 | 16 | 2007-09-26 08:00 | 2007-09-26 17:00 | 1d | 16.5d | 0.5d |  |  | Technician | 8h | 800 | 800 |
| 18 | 7.3 | Move in Belongings |  | 2d | 2007-09-27 13:00 | 2007-10-02 17:00 | 17 | 2007-09-27 13:00 | 2007-10-02 17:00 | 2d | 16d | 0d |  | 2007-10-24 17:00 | Laborer | 16h | 800 | 800 |
| 19 | 8 | Project End | milestone | 0d | 2007-10-02 17:00 | 2007-10-02 17:00 | 18 | 2007-10-02 17:00 | 2007-10-02 17:00 | 0d | 28.12d |  |  |  |  |  |  |  |

Notes:
- 13: Check cable wires.
