# My Training Manual

Schedule from MS Project, 2007-08-01 to 2007-09-26, costs in $.
Training Manual
Our Global Company
Our goal is to market quality products.

## Calendars

- Our Global Company: Mon-Fri 08:00-12:00, 13:00-17:00; Sat-Sun off. Exceptions (off unless hours are given): 2007-09-03 (Labor Day).

## Resources

| Resource | Group | Unit | Rate | Notes |
| --- | --- | --- | --- | --- |
| Writer 1 | Internal |  | 45 |  |
| Editor 1 | Internal |  | 20 |  |
| Project Manager 1 | Internal |  | 60 |  |
| Publisher | Internal |  | 48.08 |  |
| Travel Expenses | Internal |  |  |  |
| Budget - Miscellaneous | Internal |  |  |  |
| Budget - Labor | Internal |  |  |  |
| Budget - Material | Internal | reams |  |  |
| Writer 2 | Internal |  |  |  |
| Editor 2 | Internal |  |  |  |
| Account Rep 1 | Internal |  | 20 |  |
| Artist 1 | Internal |  | 25 |  |
| Subject Matter Expert | External |  | 100 |  |
| Staff Assistant 1 | Internal |  | 15 |  |
| Staff Assistant 2 | Internal |  |  | Given enough notice, this resource can work afternoons instead of mornings. |
| Glossy Paper | External | reams | 10 |  |
| Printer 1 | External |  | 500 |  |
| Plain Paper | External | reams | 7.5 |  |

## Schedule

| ID | WBS | Task | Type | Duration | Start | Finish | Predecessors | Baseline start | Baseline finish | Baseline duration | Total slack | Free slack | Constraint | Deadline | Resources | Work | Cost | Baseline cost |
| --- | --- | --- | --- | --- | --- | --- | --- | --- | --- | --- | --- | --- | --- | --- | --- | --- | --- | --- |
| 1 | 1 | Start Book | milestone | 0d | 2007-08-01 | 2007-08-01 |  | 2007-08-01 | 2007-08-01 | 0d | 0d |  |  |  |  |  |  |  |
| 2 | 2 | **Research Phase** |  | 8d | 2007-08-01 | 2007-08-10 |  | 2007-08-01 | 2007-08-10 | 8d | 0d |  |  |  |  | 88h | 3,960 | 3,960 |
| 3 | 2.1 | Investigate the Software |  | 5d | 2007-08-01 | 2007-08-07 | 1 | 2007-08-01 | 2007-08-07 | 5d | 0d |  |  |  | Writer 1 | 40h | 1,800 | 1,800 |
| 4 | 2.2 | Search the Web |  | 1d | 2007-08-08 | 2007-08-08 | 3 | 2007-08-08 | 2007-08-08 | 1d | 0d |  |  |  | Writer 1; Staff Assistant 1 | 16h | 480 | 480 |
| 5 | 2.3 | Interview Subject Matter Experts |  | 2d | 2007-08-09 | 2007-08-10 | 4 | 2007-08-09 | 2007-08-10 | 2d | 0d |  |  |  | Writer 1; Project Manager 1 | 32h | 1,680 | 1,680 |
| 6 | 3 | **Outline Phase** |  | 7d | 2007-08-13 | 2007-08-21 |  | 2007-08-13 | 2007-08-21 | 7d | 0d |  |  |  |  | 60h | 3,474.62 | 3,474.62 |
| 7 | 3.1 | Create Outline |  | 3d | 2007-08-13 | 2007-08-15 | 5 | 2007-08-13 | 2007-08-15 | 3d | 0d |  |  | 2007-08-15 | Writer 1 | 24h | 1,080 | 1,080 |
| 8 | 3.2 | Present to Publisher |  | 1d | 2007-08-16 | 2007-08-16 | 7 | 2007-08-16 | 2007-08-16 | 1d | 2d |  |  |  | Project Manager 1 [50%]; Travel Expenses [0.9%]; Publisher | 12h | 874.62 | 874.62 |
| 9 | 3.3 | Review with Subject Matter Expert |  | 1d | 2007-08-20 | 2007-08-20 | 8SS | 2007-08-20 | 2007-08-20 | 1d | 0d |  | start no earlier than 2007-08-20 |  | Writer 1; Subject Matter Expert | 16h | 1,160 | 1,160 |
| 10 | 3.4 | Revise Outline |  | 1d | 2007-08-21 | 2007-08-21 | 9 | 2007-08-21 | 2007-08-21 | 1d | 0d |  |  |  | Writer 1 | 8h | 360 | 360 |
| 11 | 4 | **Development Phase** |  | 25d | 2007-08-22 | 2007-09-26 |  | 2007-08-22 | 2007-09-26 | 25d | 0d |  |  |  |  | 332h | 9,418.46 | 9,418.46 |
| 12 | 4.1 | Write Lessons 1-5 |  | 25d | 2007-08-22 | 2007-09-26 | 10 | 2007-08-22 | 2007-09-26 | 25d | 0d |  |  |  | Writer 1 | 200h | 9,000 | 9,000 |
| 13 | 4.2 | Write Lessons 6&ndash;10 |  | 12.5d | 2007-08-22 | 2007-09-10 | 12SS | 2007-08-22 | 2007-09-10 | 12.5d | 4.21d | 0d |  |  | Writer 2 | 100h |  |  |
| 14 | 4.3 | Add Graphics |  | 1.54d | 2007-09-10 | 2007-09-12 | 13 | 2007-09-10 | 2007-09-12 | 1.54d | 4.21d | 0d |  |  | Artist 1; Staff Assistant 1; Writer 2 | 32h | 418.46 | 418.46 |
| 15 | 5 | **Edit Phase** |  | 2.52d | 2007-09-11 | 2007-09-13 |  | 2007-09-11 | 2007-09-13 | 2.52d | 4.21d |  |  |  |  | 28h | 1,080 | 1,080 |
| 16 | 5.1 | Check Grammar, Spelling, and Proofread |  | 1.5d | 2007-09-11 | 2007-09-12 | 14FS-5% | 2007-09-11 | 2007-09-12 | 1.5d | 4.21d | 0d |  |  | Editor 1; Writer 2 | 12h | 120 | 120 |
| 17 | 5.2 | Check for Technical Accuracy |  | 1d | 2007-09-12 | 2007-09-13 | 16 | 2007-09-12 | 2007-09-13 | 1d | 4.21d | 0d |  |  | Editor 1; Subject Matter Expert | 16h | 960 | 960 |
| 18 | 6 | **Review Phase** |  | 2d | 2007-09-13 | 2007-09-17 |  | 2007-09-13 | 2007-09-17 | 2d | 4.21d |  |  |  |  | 24h | 160 | 160 |
| 19 | 6.1 | Approve Editing Changes |  | 1d | 2007-09-13 | 2007-09-14 | 17 | 2007-09-13 | 2007-09-14 | 1d | 4.21d | 0d |  |  | Writer 2 | 8h |  |  |
| 20 | 6.2 | Meet with Editor |  | 1d | 2007-09-14 | 2007-09-17 | 19 | 2007-09-14 | 2007-09-17 | 1d | 4.21d | 0d |  |  | Editor 1; Writer 2 | 16h | 160 | 160 |
| 21 | 7 | **Print Phase** |  | 3d | 2007-09-17 | 2007-09-20 |  | 2007-09-17 | 2007-09-20 | 3d | 4.21d |  |  |  |  | 24h | 1,657.5 | 1,657.5 |
| 22 | 7.1 | Print Proof |  | 1d | 2007-09-17 | 2007-09-18 | 20 | 2007-09-17 | 2007-09-18 | 1d | 4.21d | 0d |  |  | Printer 1; Plain Paper [1 reams] |  | 507.5 | 507.5 |
| 23 | 7.2 | Review Proof |  | 1d | 2007-09-18 | 2007-09-19 | 22 | 2007-09-18 | 2007-09-19 | 1d | 4.21d | 0d |  |  | Project Manager 1; Writer 2; Editor 1 | 24h | 640 | 640 |
| 24 | 7.3 | Print Final |  | 1d | 2007-09-19 | 2007-09-20 | 23 | 2007-09-19 | 2007-09-20 | 1d | 4.21d | 0d |  |  | Printer 1; Glossy Paper [1 reams] |  | 510 | 510 |
| 25 | 8 | Book Complete | milestone | 0d | 2007-09-20 | 2007-09-20 | 24 | 2007-09-20 | 2007-09-20 | 0d | 4.21d |  |  |  |  |  |  |  |

Notes:
- 7: Send Outline.doc to the marketing department.
- 14: Based on the storyboard, insert appropriate graphics for the content.
- 22: Provide a hard copy proof to the project manager.
