# Training Manual

Schedule from MS Project, 2007-08-01 to 2007-10-24, costs in $.
Training Manual
Our Global Company
Our goal is to market quality products.

## Calendars

- Our Global Company: Mon-Fri 08:00-12:00, 13:00-17:00; Sat-Sun off. Exceptions (off unless hours are given): 2007-09-03 (Labor Day).

## Resources

| Resource | Group | Unit | Rate | Notes |
| --- | --- | --- | --- | --- |
| Writer 1 | Internal |  | 45 |  |
| Editor 1 | Internal |  | 20 |  |
| Project Manager 1 | Internal |  | 60 |  |
| Publisher | Internal |  | 48.08 |  |
| Travel Expenses | Internal |  |  |  |
| Budget - Miscellaneous | Internal |  |  |  |
| Budget - Labor | Internal |  |  |  |
| Budget - Material | Internal | reams |  |  |
| Writer 2 | Internal |  |  |  |
| Editor 2 | Internal |  |  |  |
| Account Rep 1 | Internal |  | 20 |  |
| Artist 1 | Internal |  | 25 |  |
| Subject Matter Expert | External |  | 100 |  |
| Staff Assistant 1 | Internal |  | 15 |  |
| Staff Assistant 2 | Internal |  |  | Given enough notice, this resource can work afternoons instead of mornings. |
| Glossy Paper | External | reams | 10 |  |
| Printer 1 | External |  | 500 |  |
| Plain Paper | External | reams | 7.5 |  |

## Schedule

| ID | WBS | Task | Type | Duration | Start | Finish | Predecessors | Total slack | Constraint | Deadline | Resources | Work | Cost |
| --- | --- | --- | --- | --- | --- | --- | --- | --- | --- | --- | --- | --- | --- |
| 1 | 1 | Start Book | milestone | 0d | 2007-08-01 | 2007-08-01 |  | 0d |  |  |  |  |  |
| 2 | 2 | **Research Phase** |  | 8d | 2007-08-01 | 2007-08-10 |  | 0d |  |  |  | 88h | 3,960 |
| 3 | 2.1 | Investigate the Software |  | 5d | 2007-08-01 | 2007-08-07 | 1 | 0d |  |  | Writer 1 | 40h | 1,800 |
| 4 | 2.2 | Search the Web |  | 1d | 2007-08-08 | 2007-08-08 | 3 | 0d |  |  | Writer 1; Staff Assistant 1 | 16h | 480 |
| 5 | 2.3 | Interview Subject Matter Experts |  | 2d | 2007-08-09 | 2007-08-10 | 4 | 0d |  |  | Writer 1; Project Manager 1 | 32h | 1,680 |
| 6 | 3 | **Outline Phase** |  | 7d | 2007-08-13 | 2007-08-21 |  | 0d |  |  |  | 60h | 3,474.62 |
| 7 | 3.1 | Create Outline |  | 3d | 2007-08-13 | 2007-08-15 | 5 | 0d |  | 2007-08-15 | Writer 1 | 24h | 1,080 |
| 8 | 3.2 | Present to Publisher |  | 1d | 2007-08-16 | 2007-08-16 | 7 | 2d |  |  | Project Manager 1 [50%]; Travel Expenses [0.9%]; Publisher | 12h | 874.62 |
| 9 | 3.3 | Review with Subject Matter Expert |  | 1d | 2007-08-20 | 2007-08-20 | 8SS | 0d | start no earlier than 2007-08-20 |  | Writer 1; Subject Matter Expert | 16h | 1,160 |
| 10 | 3.4 | Revise Outline |  | 1d | 2007-08-21 | 2007-08-21 | 9 | 0d |  |  | Writer 1 | 8h | 360 |
| 11 | 4 | **Development Phase** |  | 38.42d | 2007-08-22 | 2007-10-16 |  | 0d |  |  |  | 432h | 9,307.69 |
| 12 | 4.1 | Write Content |  | 25d | 2007-08-22 | 2007-09-26 | 10 | 0d |  |  | Writer 1; Writer 2 | 400h | 9,000 |
| 13 | 4.2 | Add Graphics |  | 2.46d | 2007-09-27 | 2007-10-16 | 12 | 0d |  |  | Artist 1; Staff Assistant 2; Writer 2 | 32h | 307.69 |
| 14 | 5 | **Edit Phase** |  | 2.52d | 2007-10-15 | 2007-10-17 |  | 0d |  |  |  | 28h | 1,080 |
| 15 | 5.1 | Check Grammar, Spelling, and Proofread |  | 1.5d | 2007-10-15 | 2007-10-16 | 13FS-5% | 0d |  |  | Editor 1; Writer 2 | 12h | 120 |
| 16 | 5.2 | Check for Technical Accuracy |  | 1d | 2007-10-16 | 2007-10-17 | 15 | 0d |  |  | Editor 1; Subject Matter Expert | 16h | 960 |
| 17 | 6 | **Review Phase** |  | 2d | 2007-10-17 | 2007-10-19 |  | 0d |  |  |  | 24h | 160 |
| 18 | 6.1 | Approve Editing Changes |  | 1d | 2007-10-17 | 2007-10-18 | 16 | 0d |  |  | Writer 2 | 8h |  |
| 19 | 6.2 | Meet with Editor |  | 1d | 2007-10-18 | 2007-10-19 | 18 | 0d |  |  | Editor 1; Writer 2 | 16h | 160 |
| 20 | 7 | **Print Phase** |  | 3d | 2007-10-19 | 2007-10-24 |  | 0d |  |  |  | 24h | 1,657.5 |
| 21 | 7.1 | Print Proof |  | 1d | 2007-10-19 | 2007-10-22 | 19 | 0d |  |  | Printer 1; Plain Paper [1 reams] |  | 507.5 |
| 22 | 7.2 | Review Proof |  | 1d | 2007-10-22 | 2007-10-23 | 21 | 0d |  |  | Project Manager 1; Writer 2; Editor 1 | 24h | 640 |
| 23 | 7.3 | Print Final |  | 1d | 2007-10-23 | 2007-10-24 | 22 | 0d |  |  | Printer 1; Glossy Paper [1 reams] |  | 510 |
| 24 | 8 | Book Complete | milestone | 0d | 2007-10-24 | 2007-10-24 | 23 | 0d |  |  |  |  |  |

Notes:
- 7: Send Outline.doc to the marketing department.
- 13: Based on the storyboard, insert appropriate graphics for the content.
- 21: Provide a hard copy proof to the project manager.
