# CSS Training Manual

Schedule from MS Project, 2007-08-15 to 2007-09-10, costs in $.
Training Manual
Out Global Company
Our goal is to market quality products.

## Calendars

- Our Global Company: Mon-Fri 08:00-12:00, 13:00-17:00; Sat-Sun off. Exceptions (off unless hours are given): 2007-09-03 (Labor Day).

## Resources

| Resource | Group | Unit | Rate | Cost per use | Notes |
| --- | --- | --- | --- | --- | --- |
| Writer 1 | Internal |  | 47.25 |  |  |
| Editor 1 | Internal |  | 17 |  |  |
| Printer 1 | Internal |  | 10 |  |  |
| Artist 1 | Internal |  | 25 |  |  |
| Project Manager 1 | Internal |  | 60 |  |  |
| Staff Assistant 1 | Internal |  | 12 |  |  |
| Staff Assistant 2 | Internal |  | 12 |  | Given enough notice, this resource can work afternoons instead of mornings. |
| Glossy Paper | External | reams | 10 |  |  |
| Plain Paper | External | reams | 7.5 | 100 |  |
| Travel Expenses | Internal |  |  |  |  |
| Editor 2 | Internal |  | 17 |  |  |
| Writer 2 | Internal |  | 45 |  |  |

## Schedule

| ID | WBS | Task | Duration | Start | Finish | Predecessors | Baseline start | Baseline finish | Baseline duration | Total slack | Free slack | Constraint | Resources | Work | Cost | Baseline cost |
| --- | --- | --- | --- | --- | --- | --- | --- | --- | --- | --- | --- | --- | --- | --- | --- | --- |
| 1 | 1 | **Research Phase** | 12d | 2007-08-17 | 2007-09-04 |  | 2005-08-15 | 2005-08-24 | 8d | 4d |  |  |  | 88h | 3,695 | 3,936 |
| 2 | 1.1 | Investigate the Software | 5d | 2007-08-27 | 2007-08-31 |  | 2005-08-17 | 2005-08-23 | 5d | 4d | 0d |  | Writer 1 [50%]; Writer 2 [50%] | 40h | 1,845 | 1,800 |
| 3 | 1.2 | Search the Web | 1d | 2007-09-04 | 2007-09-04 | 2 | 2005-08-24 | 2005-08-24 | 1d | 4d |  |  | Writer 1; Staff Assistant 1 | 16h | 474 | 456 |
| 4 | 1.3 | Interview Subject Matter Experts | 2d | 2007-08-17 | 2007-08-20 |  | 2005-08-15 | 2005-08-16 | 2d | 14d |  |  | Writer 1 [50%]; Project Manager 1 [50%] | 32h | 1,376 | 1,680 |
| 5 | 2 | **Outline Phase** | 2d | 2007-08-15 | 2007-08-16 |  | 2005-08-15 | 2005-08-22 | 6d | 0d |  |  |  | 16h | 1,616 | 1,200 |
| 6 | 2.1 | Draw Content Outline | 1d | 2007-08-15 | 2007-08-15 |  |  |  |  | 18d |  |  |  |  |  |  |
| 7 | 2.2 | Present to Publisher | 2d | 2007-08-15 | 2007-08-16 |  | 2005-08-17 | 2005-08-18 | 2d | 16d |  |  | Project Manager 1 [50%]; Travel Expenses [0.6%] | 8h | 1,480 | 480 |
| 8 | 2.3 | Review Outline | 1d | 2007-08-15 | 2007-08-15 |  | 2005-08-22 | 2005-08-22 | 1d | 0d |  |  | Editor 2 | 8h | 136 |  |
| 9 | 3 | **Development Phase** | 10d | 2007-08-16 | 2007-08-29 |  | 2005-08-23 | 2005-09-06 | 10d | 0d |  |  |  | 120h | 4,690 | 3,600 |
| 10 | 3.1 | Write Lesson 1-5 | 5d | 2007-08-16 | 2007-08-22 | 8 | 2005-08-23 | 2005-08-29 | 5d | 0d |  |  | Writer 1 | 40h | 1,890 | 1,800 |
| 11 | 3.2 | Write Lesson 6-10 | 5d | 2007-08-16 | 2007-08-22 | 10SS | 2005-08-23 | 2005-08-29 | 5d | 0d |  | as late as possible | Writer 2 | 40h | 1,800 | 1,800 |
| 12 | 3.3 | Create Graphics | 5d | 2007-08-23 | 2007-08-29 | 11 | 2005-08-30 | 2005-09-06 | 5d | 0d |  |  | Artist 1 | 40h | 1,000 |  |
| 13 | 4 | **Edit Phase** | 1d | 2007-08-27 | 2007-08-28 |  | 2005-09-01 | 2005-09-07 | 3d | 0d |  |  |  | 16h | 272 | 272 |
| 14 | 4.1 | Check for Grammar Inconsistencies | 1d | 2007-08-27 | 2007-08-28 | 12FS-5% | 2005-09-01 | 2005-09-02 | 1d | 0d |  |  | Editor 2; Editor 1 | 16h | 272 | 272 |
| 15 | 5 | **Review Phase** | 5.5d | 2007-08-28 | 2007-09-05 |  | 2005-09-07 | 2005-09-19 | 8d | 0d |  |  |  | 64h | 1,088 |  |
| 16 | 5.1 | Quality Review 1 | 2.5d | 2007-08-28 | 2007-08-30 | 14 | 2005-09-07 | 2005-09-14 | 5d | 0d |  |  | Editor 1; Editor 2 | 40h | 680 |  |
| 17 | 5.2 | Quality Review 2 | 3d | 2007-08-31 | 2007-09-05 | 16 | 2005-09-14 | 2005-09-19 | 3d | 0d |  |  | Editor 2 | 24h | 408 |  |
| 18 | 6 | Print Phase | 3d | 2007-09-06 | 2007-09-10 | 17 | 2005-09-19 | 2005-09-22 | 3d | 0d |  |  | Project Manager 1 | 24h | 1,440 |  |

Notes:
- 12: Upload graphic files with correct naming conventions on Documentum.
- 16: Print Quality report and upload on QS.
