# XML Training Manual

Schedule from MS Project, 2007-10-03 to 2007-10-29, costs in $.
XML Training Manual
Our Global Company
Our goal is to market quality products.

## Calendars

- Our Global Company: Mon-Fri 08:00-12:00, 13:00-17:00; Sat-Sun off.

## Resources

| Resource | Group | Unit | Rate | Cost per use | Notes |
| --- | --- | --- | --- | --- | --- |
| Writer 1 | Internal |  | 47.25 |  |  |
| Editor 1 | Internal |  | 17 |  |  |
| Printer 1 | Internal |  | 10 |  |  |
| Artist 1 | Internal |  | 25 |  |  |
| Project Manager 1 | Internal |  | 60 |  |  |
| Staff Assistant 1 | Internal |  | 12 |  |  |
| Staff Assistant 2 | Internal |  | 12 |  | Given enough notice, this resource can work afternoons instead of mornings. |
| Glossy Paper | External | reams | 150 |  |  |
| Plain Paper | External | reams | 100 | 100 |  |
| Travel Expenses | Internal |  |  |  |  |
| Editor 2 | Internal |  | 17 |  |  |
| Writer 2 | Internal |  | 45 |  |  |
| Budget - Labor |  |  |  |  |  |
| Budget - Material |  | reams |  |  |  |
| Budget - Travel |  |  |  |  |  |
| Writer 3 |  |  |  |  |  |

## Schedule

| ID | WBS | Task | Duration | Start | Finish | Predecessors | Baseline start | Baseline finish | Baseline duration | Total slack | Free slack | Constraint | Deadline | Resources | Work | Cost | Baseline cost |
| --- | --- | --- | --- | --- | --- | --- | --- | --- | --- | --- | --- | --- | --- | --- | --- | --- | --- |
| 1 | 1 | **Research Phase** | 17d | 2007-10-05 | 2007-10-29 |  | 2005-08-15 | 2005-08-24 | 8d | 0d |  |  |  |  | 88h | 3,695 | 3,936 |
| 2 | 1.1 | Interview Subject Matter Experts | 2d | 2007-10-05 | 2007-10-08 |  | 2005-08-15 | 2005-08-16 | 2d | 0d |  |  |  | Writer 1 [50%]; Project Manager 1 [50%] | 32h | 1,376 | 1,680 |
| 3 | 1.2 | Investigate | 5d | 2007-10-22 | 2007-10-26 | 2 | 2005-08-17 | 2005-08-23 | 5d | 0d |  |  |  | Writer 1 [50%]; Writer 2 [50%] | 40h | 1,845 | 1,800 |
| 4 | 1.3 | Search the Web | 1d | 2007-10-29 | 2007-10-29 | 3 | 2005-08-24 | 2005-08-24 | 1d | 0d |  |  |  | Writer 1; Staff Assistant 1 | 16h | 474 | 456 |
| 5 | 2 | **Outline Phase** | 4d | 2007-10-03 | 2007-10-08 |  | 2005-08-15 | 2005-08-22 | 6d | 4d |  |  |  |  | 40h | 2,852 | 1,200 |
| 6 | 2.1 | Draw Content Outline | 2d | 2007-10-03 | 2007-10-04 |  | 2005-08-15 | 2005-08-16 | 2d | 4d | 0d |  | 2007-10-10 | Writer 1 | 16h | 756 | 720 |
| 7 | 2.2 | Present to Publisher | 2d | 2007-10-05 | 2007-10-08 | 6 | 2005-08-17 | 2005-08-18 | 2d | 10d | 0d |  |  | Project Manager 1 [50%]; Travel Expenses [0.6%] | 8h | 1,480 | 480 |
| 8 | 2.3 | Review with Subject Matter Expert | 1d | 2007-10-05 | 2007-10-05 | 7SS | 2005-08-19 | 2005-08-19 | 1d | 10d | 0d | start no earlier than 2006-10-07 | 2007-11-11 | Project Manager 1 | 8h | 480 |  |
| 9 | 2.4 | Review Outline | 1d | 2007-10-08 | 2007-10-08 | 8 | 2005-08-22 | 2005-08-22 | 1d | 10d | 0d |  |  | Editor 2 | 8h | 136 |  |
| 10 | 3 | **Development Phase** | 9d | 2007-10-03 | 2007-10-15 |  | 2005-08-23 | 2005-09-06 | 10d | 10d |  |  |  |  | 80h | 2,890 | 3,600 |
| 11 | 3.1 | Write Lessons | 5d | 2007-10-09 | 2007-10-15 | 9 | 2005-08-23 | 2005-08-29 | 5d | 10d |  |  |  | Writer 1 | 40h | 1,890 | 1,800 |
| 12 | 3.2 | Create Graphics | 5d | 2007-10-03 | 2007-10-09 |  | 2005-08-30 | 2005-09-06 | 5d | 10.5d | 0d |  |  | Artist 1 | 40h | 1,000 |  |
| 13 | 3.3 | Add Graphics | 2d | 2007-10-03 | 2007-10-04 |  |  |  |  | 17d |  |  |  |  |  |  |  |
| 14 | 4 | **Edit Phase** | 3d | 2007-10-05 | 2007-10-10 |  | 2005-09-01 | 2005-09-07 | 3d | 10.5d |  |  |  |  | 32h | 544 | 272 |
| 15 | 4.1 | Check for Grammar Inconsistencies | 1d | 2007-10-05 | 2007-10-08 | 12FS-5% | 2005-09-01 | 2005-09-02 | 1d | 10.5d | 0d |  |  | Editor 2; Editor 1 | 16h | 272 | 272 |
| 16 | 4.2 | Check for Adherence to Company Styleguide | 2d | 2007-10-08 | 2007-10-10 | 15 | 2005-09-02 | 2005-09-07 | 2d | 10.5d | 0d |  | 2007-11-06 | Editor 2 | 16h | 272 |  |
| 17 | 5 | **Review Phase** | 3d | 2007-10-10 | 2007-10-15 |  | 2005-09-07 | 2005-09-19 | 8d | 10.5d |  |  |  |  | 48h | 816 |  |
| 18 | 5.1 | Quality Reviews | 3d | 2007-10-10 | 2007-10-15 | 16 | 2005-09-07 | 2005-09-14 | 5d | 10.5d |  |  |  | Editor 1; Editor 2 | 48h | 816 |  |
| 19 | 6 | Print Phase | 3d | 2007-10-03 | 2007-10-05 |  | 2005-09-19 | 2005-09-22 | 3d | 16d |  |  |  | Project Manager 1 | 24h | 1,440 |  |

Notes:
- 6: Post Outline.doc to the Marketing Web Page.
- 12: Upload graphic files with correct naming conventions on Documentum.
- 18: Print Quality report and upload on QS.
