# Training Manual

Schedule from MS Project, 2007-08-01 to 2007-10-09, costs in $.
Training Manual
Our Global Company
Our goal is to market quality products.

## Calendars

- Our Global Company: Mon-Fri 08:00-12:00, 13:00-17:00; Sat-Sun off. Exceptions (off unless hours are given): 2007-09-03 (Labor Day).

## Resources

| Resource | Group | Unit | Rate | Notes |
| --- | --- | --- | --- | --- |
| Writer 1 | Internal |  | 45 |  |
| Editor 1 | Internal |  | 20 |  |
| Project Manager 1 | Internal |  | 60 |  |
| Publisher | Internal |  | 48.08 |  |
| Travel Expenses | Internal |  |  |  |
| Budget - Miscellaneous | Internal |  |  |  |
| Budget - Labor | Internal |  |  |  |
| Budget - Material | Internal | reams |  |  |
| Writer 2 | Internal |  |  |  |
| Editor 2 | Internal |  |  |  |
| Account Rep 1 | Internal |  | 20 |  |
| Artist 1 | Internal |  | 25 |  |
| Subject Matter Expert | External |  | 100 |  |
| Staff Assistant 1 | Internal |  | 15 |  |
| Staff Assistant 2 | Internal |  |  | Given enough notice, this resource can work afternoons instead of mornings. |
| Glossy Paper | External | reams | 10 |  |
| Printer 1 | External |  | 500 |  |
| Plain Paper | External | reams | 7.5 |  |

## Schedule

| ID | WBS | Task | Type | Duration | Start | Finish | Predecessors | Total slack | Free slack | Constraint | Deadline | Resources | Work | Cost |
| --- | --- | --- | --- | --- | --- | --- | --- | --- | --- | --- | --- | --- | --- | --- |
| 1 | 1 | Start Book | milestone | 0d | 2007-08-01 | 2007-08-01 |  | -1d | 0d |  |  |  |  |  |
| 2 | 2 | **Research Phase** |  | 8d | 2007-08-01 | 2007-08-10 |  | 0d |  |  |  |  | 88h | 3,960 |
| 3 | 2.1 | Investigate the Software |  | 5d | 2007-08-01 | 2007-08-07 | 1 | 0d |  |  |  | Writer 1 | 40h | 1,800 |
| 4 | 2.2 | Search the Web |  | 1d | 2007-08-08 | 2007-08-08 | 3 | 0d |  |  |  | Writer 1; Staff Assistant 1 | 16h | 480 |
| 5 | 2.3 | Interview Subject Matter Experts |  | 2d | 2007-08-09 | 2007-08-10 | 4 | 0d |  |  |  | Writer 1; Project Manager 1 | 32h | 1,680 |
| 6 | 3 | **Outline Phase** |  | 7d | 2007-08-13 | 2007-08-21 |  | 0d |  |  |  |  | 28h | 1,570 |
| 7 | 3.1 | Create Outline |  | 3d | 2007-08-13 | 2007-08-15 | 5 | 0d |  |  | 2007-08-15 | Writer 1 | 24h | 1,080 |
| 8 | 3.2 | Present to Publisher |  | 1d | 2007-08-16 | 2007-08-16 | 7 | 2d |  |  |  | Project Manager 1 [50%]; Travel Expenses [0.3%] | 4h | 490 |
| 9 | 3.3 | Review with Subject Matter Expert |  | 1d | 2007-08-20 | 2007-08-20 | 8SS | 0d |  | start no earlier than 2007-08-20 |  |  |  |  |
| 10 | 3.4 | Revise Outline |  | 1d | 2007-08-21 | 2007-08-21 | 9 | 0d |  |  |  |  |  |  |
| 11 | 4 | **Development Phase** |  | 27.5d | 2007-08-22 | 2007-10-01 |  | 0d |  |  |  |  |  |  |
| 12 | 4.1 | Write Content |  | 25d | 2007-08-22 | 2007-09-26 | 10 | 0d |  |  |  |  |  |  |
| 13 | 4.2 | Add Graphics |  | 2.5d | 2007-09-27 | 2007-10-01 | 12 | 0d |  |  |  |  |  |  |
| 14 | 5 | **Edit Phase** |  | 2.5d | 2007-09-28 | 2007-10-02 |  | 0d |  |  |  |  |  |  |
| 15 | 5.1 | Check Grammar, Spelling, and Proofread |  | 1.5d | 2007-09-28 | 2007-10-01 | 13FS-5% | 0d |  |  |  |  |  |  |
| 16 | 5.2 | Check for Technical Accuracy |  | 1d | 2007-10-01 | 2007-10-02 | 15 | 0d |  |  |  |  |  |  |
| 17 | 6 | **Review Phase** |  | 2d | 2007-10-02 | 2007-10-04 |  | 0d |  |  |  |  |  |  |
| 18 | 6.1 | Approve Editing Changes |  | 1d | 2007-10-02 | 2007-10-03 | 16 | 0d |  |  |  |  |  |  |
| 19 | 6.2 | Meet with Editor |  | 1d | 2007-10-03 | 2007-10-04 | 18 | 0d |  |  |  |  |  |  |
| 20 | 7 | **Print Phase** |  | 3d | 2007-10-04 | 2007-10-09 |  | 0d |  |  |  |  |  |  |
| 21 | 7.1 | Print Proof |  | 1d | 2007-10-04 | 2007-10-05 | 19 | 0d |  |  |  |  |  |  |
| 22 | 7.2 | Review Proof |  | 1d | 2007-10-05 | 2007-10-08 | 21 | 0d |  |  |  |  |  |  |
| 23 | 7.3 | Print Final |  | 1d | 2007-10-08 | 2007-10-09 | 22 | 0d |  |  |  |  |  |  |
| 24 | 8 | Book Complete | milestone | 0d | 2007-10-09 | 2007-10-09 | 23 | 0d |  |  |  |  |  |  |

Notes:
- 7: Send Outline.doc to the marketing department.
- 13: Based on the storyboard, insert appropriate graphics for the content.
- 21: Provide a hard copy proof to the project manager.
